# stage

Schedule from MS Project, 2007-03-15 to 2007-09-25, 7 hours a day, A marks actual dates.
IDEALX

## Calendars

- Standard: Mon-Fri 09:00-12:00, 14:00-18:00; Sat-Sun off.

## Schedule

| ID | Task | Type | Duration | Start | Finish | Predecessors | Complete | Total slack | Constraint |
| --- | --- | --- | --- | --- | --- | --- | --- | --- | --- |
| 1 | Etude |  | 7d | 2007-03-15 A | 2007-03-23 A |  | 100% |  | start no earlier than 2007-03-15 |
| 2 | Preuve du concept |  | 7d | 2007-03-26 A | 2007-04-03 A | 1 | 100% |  |  |
| 3 | Etude et test d'un connecteur SOAP coté PKI |  | 20d | 2007-04-04 A | 2007-05-01 A | 2 | 100% |  |  |
| 4 | Adaptation d'AEP pour la démonstration |  | 17d | 2007-04-04 A | 2007-04-26 A | 2 | 100% |  |  |
| 5 | Préparation de la démonstration |  | 3d | 2007-04-27 A | 2007-05-01 A | 4 | 100% |  |  |
| 6 | Démonstration | milestone | 1d? | 2007-05-22 | 2007-05-22 | 5 |  | 76d | start no earlier than 2007-05-22 |
| 7 | Intégration de la PKI 3.4 |  | 25d | 2007-05-02 | 2007-06-05 |  |  | 5d | start no earlier than 2007-05-02 |
| 8 | Auto-formation |  | 5d | 2007-06-06 A | 2007-06-12 A | 6 | 100% |  | start no earlier than 2007-06-06 |
| 9 | Adaptation d'AEP pour la V1 |  | 23d | 2007-06-13 A | 2007-07-13 A | 8 | 100% |  |  |
| 10 | Préparation d'une maquette |  | 5d? | 2007-07-13 A | 2007-07-19 A |  | 100% |  | finish no earlier than 2007-07-19 |
| 11 | Présentation de la maquette | milestone | 1d? | 2007-07-20 | 2007-07-20 | 10 |  | 47d | start no earlier than 2007-07-20 |
| 12 | Haute dispo et équilibrage de charge d'OpenTrust TSA |  | 7d? | 2007-08-02 A | 2007-08-10 A |  | 100% |  | start no earlier than 2007-08-02 |
| 13 | Préparation d'une seconde maquette |  | 13d? | 2007-08-09 A | 2007-08-27 A |  | 100% |  | finish no earlier than 2007-08-27 |
| 14 | Présentation de la seconde maquette | milestone | 1d? | 2007-08-28 | 2007-08-28 | 13 |  | 20d |  |
| 15 | Sortie d'OpenTrust PKI 3.4.3 | milestone | 1d? | 2007-08-16 | 2007-08-16 |  |  | 14d | start no earlier than 2007-08-16 |
| 16 | Sortie d'OpenTrust PKI 3.4.4 | milestone | 1d? | 2007-09-05 | 2007-09-05 |  |  | 3d | start no earlier than 2007-09-05 |
| 17 | Support du mode complet de CMC |  | 63d | 2007-06-06 A | 2007-08-31 A | 6 | 100% |  | start no earlier than 2007-06-06 |
| 18 | Documentation |  | 122d | 2007-03-15 A | 2007-08-31 A |  | 100% |  |  |
| 19 | Préparation d'une démonstration |  | 8d? | 2007-08-29 A | 2007-09-07 A |  | 100% |  | start no earlier than 2007-08-29 |
| 20 | Présentation de la démonstration | milestone | 1d? | 2007-09-10 | 2007-09-10 | 19 |  | 11d |  |
| 21 | Projet Armageddon |  | 9d? | 2007-09-11 A | 2007-09-21 A | 20 | 100% |  | start no earlier than 2007-09-11 |
| 22 | C3I | milestone | 1d? | 2007-09-25 | 2007-09-25 | 21 |  | 0d | start no earlier than 2007-09-25 |
